# MARS-Dec20-2007

How a schedule from MS Project changed from version to version. A marks actual dates.

## Version 1 (saved 2007-12-21, file MARS-Dec20-2007.mpp)

| ID | WBS | Task | Duration | Start | Finish | Predecessors | Complete | Total float | Constraint |
| --- | --- | --- | --- | --- | --- | --- | --- | --- | --- |
| 1 | 1 | **LV System Closeup** | 23.35d | 2007-12-21 A | 2008-01-28 |  | 6% | 2.75d |  |
| 2 | 1.1 | **Dry end** | 5.25d | 2008-01-21 | 2008-01-28 |  |  | 2.75d |  |
| 3 |  | Install o-rings | 0.3d | 2008-01-21 | 2008-01-21 |  |  | 2.75d |  |
| 4 |  | Verify operations | 0.1d | 2008-01-21 | 2008-01-21 | 3 |  | 2.75d |  |
| 5 |  | Workmanship review | 0.5d | 2008-01-21 | 2008-01-28 | 4 |  | 2.75d |  |
| 6 | 1.2 | **Wet end** | 14.29d | 2007-12-21 A | 2008-01-15 |  | 16% | 11.81d |  |
| 7 |  | Build up resistor bank | 1d | 2007-12-21 | 2007-12-21 |  |  | 0d |  |
| 8 |  | Duplicate flash disk | 0.5d | 2007-12-27 | 2007-12-27 |  |  | 23.1d |  |
| 9 |  | Swap in flight CPU (104) | 0.5d | 2007-12-21 A | 2007-12-21 A |  | 100% |  | start no earlier than 2007-12-21 |
| 10 |  | Get Kevin's docs in O&M manual | 0.1d | 2007-12-28 | 2007-12-28 |  |  | 23d |  |
| 11 |  | Install pc104 connector stops | 0.5d | 2007-12-21 A | 2007-12-21 A | 9 | 100% |  | start no earlier than 2007-12-21 |
| 12 |  | Install tie rods | 0.1d | 2007-12-21 | 2007-12-21 | 11 |  | 1.4d |  |
| 13 |  | Resister Design Verification | 0.5d | 2007-12-21 | 2007-12-26 | 12 |  | 1.4d |  |
| 14 |  | Install resistor bank | 1d | 2007-12-26 | 2007-12-27 | 7, 13 |  | 0.5d |  |
| 15 |  | Verify stability | 0.5d | 2007-12-27 | 2007-12-27 | 14 |  | 16.81d |  |
| 16 |  | Route comms cables | 1d | 2007-12-28 | 2007-12-28 | 15 |  | 16.81d |  |
| 17 |  | Workmanship review | 0.5d | 2007-12-31 | 2008-01-04 | 16 |  | 16.81d |  |
| 18 |  | Verify operation | 0.25d | 2008-01-04 | 2008-01-15 | 17 |  | 11.81d |  |
| 19 | 1.3 | **Open System testing** | 4.67d | 2007-12-21 | 2007-12-31 |  |  | 4.81d |  |
| 20 |  | Quick and dirty dyno test | 0.33d | 2007-12-21 | 2007-12-21 |  |  | 8.11d |  |
| 21 |  | Test 2nd 10 kV PS | 0.53d | 2007-12-21 | 2007-12-26 | 20 |  | 8.11d |  |
| 22 |  | dry run system test | 1.6d | 2007-12-21 | 2007-12-31 |  |  | 4.81d |  |
| 23 | 1.4 | **Close and Fill** | 8.79d | 2007-12-21 | 2008-01-07 |  |  | 4.15d |  |
| 24 |  | Filter FC77 | 3d | 2007-12-21 | 2007-12-28 |  |  | 4.15d |  |
| 25 |  | close and fill | 2d | 2007-12-31 | 2008-01-07 | 24, 19 |  | 4.81d |  |
| 26 | 1.5 | **Closed system testing** | 1.5d | 2008-01-14 | 2008-01-15 |  |  | 0.6d |  |
| 27 |  | Operational check | 0.5d | 2008-01-14 | 2008-01-14 | 23 |  | 0.6d |  |
| 28 |  | system test | 1d | 2008-01-14 | 2008-01-15 | 27 |  | 0.6d |  |
| 29 |  | Build node | 1d | 2008-01-15 | 2008-01-16 | 26 |  | 0.6d |  |
| 30 | 3 | **Build Test Tank MV Rack** | 16.1d | 2007-12-21 | 2008-01-17 |  |  | 5d |  |
| 31 | 3.1 | **Design** | 2d | 2007-12-31 | 2008-01-03 | 22 |  | 6.93d |  |
| 32 | 3.1.1 | **Switching/grounding circuit** | 1d | 2007-12-31 | 2008-01-02 |  |  | 7.93d |  |
| 33 |  | interlocks, lights, etc | 1d | 2007-12-31 | 2008-01-02 |  |  | 7.93d |  |
| 34 |  | rack wiring | 2d | 2007-12-31 | 2008-01-03 |  |  | 6.93d |  |
| 35 |  | Artificial line shelf | 2d | 2007-12-21 | 2008-01-04 |  |  | 18.43d |  |
| 36 |  | Build up and wire rack | 1.67d | 2008-01-03 | 2008-01-14 | 31 |  | 2.12d |  |
| 37 |  | Sea water ground plates | 1d | 2008-01-08 | 2008-01-09 |  |  | 5.31d |  |
| 38 | 3.5 | **Fiber run B to D** | 16.1d | 2007-12-21 | 2008-01-17 |  |  | 0d |  |
| 39 |  | Install building anchor points | 1d | 2007-12-21 | 2007-12-21 |  |  | 5d |  |
| 40 |  | Run cable | 1d | 2008-01-07 | 2008-01-08 | 39 |  | 2.21d |  |
| 41 |  | Terminate cable | 1d | 2008-01-08 | 2008-01-09 | 40 |  | 2.21d |  |
| 42 |  | Test | 1d | 2008-01-14 | 2008-01-17 | 41 |  | 0d |  |
| 43 | 4 | **Tank testing** | 7d | 2008-01-17 | 2008-01-28 | 29, 36, 37, 38 |  | 0d |  |
| 44 |  | Build up test system | 2d | 2008-01-17 | 2008-01-21 |  |  | 0d |  |
| 45 |  | Test | 5d | 2008-01-21 | 2008-01-28 | 44 |  | 0d |  |
| 46 | 5 | **End of Island** | 25.1d | 2007-12-21 | 2008-01-30 |  |  | 0d |  |
| 47 |  | Ground plate and wiring | 1d | 2008-01-02 | 2008-01-14 |  |  | 11.29d |  |
| 48 |  | Build up DCS rack | 5.32d | 2007-12-21 | 2008-01-03 |  |  | 18.43d |  |
| 49 |  | Rebuild MV rack | 2d | 2008-01-28 | 2008-01-30 | 43 |  | 0d |  |
| 50 |  | MOB | 1d | 2008-01-28 | 2008-01-29 | 45 |  | 1d |  |
| 51 |  | Deployment | 1d | 2008-01-30 | 2008-01-31 | 50, 46 |  | 0d |  |

## Version 2 (saved 2007-12-21, file MARS-Dec21-2007a.mpp)

Last finish 2008-01-31 → 2008-01-29 (-2d).

Removed: 10 Get Kevin's docs in O&M manual; 16 Route comms cables; 23 Close and Fill; 33 interlocks, lights, etc

Changed:

| ID | Task | Start | Finish | Duration | Complete | Total float | Predecessors | Other |
| --- | --- | --- | --- | --- | --- | --- | --- | --- |
| 1 | **LV System Closeup** |  | 2008-01-28 → 2008-01-08 (-20d) | 23.35d → 9.62d | 6% → 8% | 2.75d → 14.62d |  |  |
| 2 | **Dry end** | 2008-01-21 → 2007-12-21 (-31d) | 2008-01-28 → 2007-12-27 (-32d) | 5.25d → 2.02d |  | 2.75d → 20.73d |  |  |
| 3 | Install o-rings | 2008-01-21 → 2007-12-21 (-31d) | 2008-01-21 → 2007-12-21 (-31d) |  |  | 2.75d → 20.73d |  | resources Ken → none |
| 4 | Verify operations | 2008-01-21 → 2007-12-21 (-31d) | 2008-01-21 → 2007-12-21 (-31d) |  |  | 2.75d → 20.73d |  | resources Ken → none |
| 5 | Workmanship review | 2008-01-21 → 2007-12-21 (-31d) | 2008-01-28 → 2007-12-27 (-32d) |  |  | 2.75d → 20.73d |  | resources Ken; Gene → none |
| 6 | **Wet end** |  | 2008-01-15 → 2008-01-02 (-13d) | 14.29d → 5.62d | 16% → 12% | 11.81d → 18.62d |  |  |
| 8 | Duplicate flash disk | 2007-12-27 → 2007-12-28 (+1d) | 2007-12-27 → 2007-12-28 (+1d) |  |  | 23.1d → 20.58d |  |  |
| 11 | Install tie rods |  |  | 0.1d → 0.2d |  | 1.4d → -1.2d |  | resources Ken; LV → LV |
| 12 | Resister Design Verification |  |  | 0.5d → 2d |  | 1.4d → -2.5d |  | resources Ed; Ken; LV; MV → Ed |
| 13 | Install resistor bank, route comm cables | 2007-12-26 → 2007-12-27 (+1d) | 2007-12-27 → 2007-12-31 (+4d) | 1d → 2.5d |  | 0.5d → -2.5d | 7, 12 → 7, 12, 11 | was named Install resistor bank |
| 14 | Verify stability | 2007-12-27 → 2007-12-31 (+4d) | 2007-12-27 → 2007-12-31 (+4d) |  |  | 16.81d → 0d |  | resources none → Ed |
| 15 | Workmanship review | 2007-12-31 → 2008-01-02 (+2d) | 2008-01-04 → 2008-01-02 (-2d) |  |  | 16.81d → 0d | Route comms cables → 14 | resources Ken; Gene; LV → Craig |
| 16 | Verify operation | 2008-01-04 → 2008-01-02 (-2d) | 2008-01-15 → 2008-01-02 (-13d) | 0.25d → 0.12d |  | 11.81d → 0d |  |  |
| 17 | **Open System testing** | 2007-12-21 → 2008-01-02 (+12d) | 2007-12-31 → 2008-01-08 (+8d) | 4.67d → 4d |  | 4.81d → 0d |  |  |
| 18 | Quick and dirty dyno test | 2007-12-21 → 2008-01-02 (+12d) | 2007-12-21 → 2008-01-03 (+13d) | 0.33d → 0.5d |  | 8.11d → 0d | none → 16 |  |
| 19 | Test 2nd 10 kV PS | 2007-12-21 → 2008-01-03 (+13d) | 2007-12-26 → 2008-01-03 (+8d) | 0.53d → 0.5d |  | 8.11d → 0d |  |  |
| 20 | dry run system test | 2007-12-21 → 2008-01-03 (+13d) | 2007-12-31 → 2008-01-08 (+8d) | 1.6d → 3d |  | 4.81d → 0d | none → 19 |  |
| 21 | Filter FC77 |  | 2007-12-28 → 2007-12-27 (-1d) |  |  | 4.15d → 19.75d |  | resources Ken → none |
| 22 | close and fill | 2007-12-31 → 2008-01-08 (+8d) | 2008-01-07 → 2008-01-10 (+3d) | 2d → 1.5d |  | 4.81d → 13.12d | 21, 17 → 17, 5, 21 |  |
| 23 | **Closed system testing** | 2008-01-14 → 2007-12-21 (-24d) | 2008-01-15 → 2008-01-10 (-5d) | 1.5d → 11.5d |  | 0.6d → 0.5d |  |  |
| 24 | Operational check | 2008-01-14 → 2007-12-21 (-24d) | 2008-01-14 → 2007-12-21 (-24d) |  |  | 0.6d → 0.5d | Close and Fill → none |  |
| 25 | system test | 2008-01-14 → 2008-01-03 (-11d) | 2008-01-15 → 2008-01-10 (-5d) |  |  | 0.6d → 1.75d |  |  |
| 26 | Build node | 2008-01-15 → 2008-01-10 (-5d) | 2008-01-16 → 2008-01-14 (-2d) | 1d → 2.5d |  | 0.6d → 1.25d |  |  |
| 27 | **Build Test Tank MV Rack** |  | 2008-01-17 → 2008-01-16 (-1d) | 16.1d → 15.25d |  | 5d → 7d |  |  |
| 28 | **Design** | 2007-12-31 → 2008-01-08 (+8d) | 2008-01-03 → 2008-01-11 (+8d) | 2d → 2.62d |  | 6.93d → 0d |  | resources Ed → none |
| 29 | Switching/grounding circuit | 2007-12-31 → 2008-01-08 (+8d) | 2008-01-02 → 2008-01-09 (+7d) |  |  | 7.93d → 1.62d |  | resources none → Ed |
| 30 | rack wiring | 2007-12-31 → 2008-01-08 (+8d) | 2008-01-03 → 2008-01-11 (+8d) |  |  | 6.93d → 0d |  | resources none → Ed |
| 31 | Artificial line shelf |  | 2008-01-04 → 2007-12-26 (-9d) |  |  | 18.43d → 22.25d |  | resources Gene; Larry → Larry |
| 32 | Build up and wire rack | 2008-01-03 → 2008-01-11 (+8d) | 2008-01-14 → 2008-01-16 (+2d) | 1.67d → 3d |  | 2.12d → 0d |  | resources Ken; Tom → Tom |
| 33 | Sea water ground plates | 2008-01-08 → 2008-01-14 (+6d) | 2008-01-09 → 2008-01-15 (+6d) |  |  | 5.31d → 0.75d |  |  |
| 34 | **Fiber run B to D** |  | 2008-01-17 → 2008-01-11 (-6d) | 16.1d → 12.5d |  | 0d → 2.75d |  |  |
| 36 | Run cable | 2008-01-07 → 2008-01-02 (-5d) | 2008-01-08 → 2008-01-02 (-6d) |  |  | 2.21d → 3d |  |  |
| 37 | Terminate cable | 2008-01-08 → 2008-01-03 (-5d) | 2008-01-09 → 2008-01-03 (-6d) |  |  | 2.21d → 3d |  |  |
| 38 | Test | 2008-01-14 → 2008-01-10 (-4d) | 2008-01-17 → 2008-01-11 (-6d) |  |  | 0d → 2.75d |  | resources Ken → Gene |
| 39 | **Tank testing** | 2008-01-17 → 2008-01-16 (-1d) | 2008-01-28 → 2008-01-24 (-4d) | 7d → 6d |  |  |  |  |
| 40 | Build up test system | 2008-01-17 → 2008-01-16 (-1d) | 2008-01-21 → 2008-01-18 (-3d) |  |  |  |  |  |
| 41 | Test | 2008-01-21 → 2008-01-18 (-3d) | 2008-01-28 → 2008-01-24 (-4d) | 5d → 4d |  |  |  | resources Gene → Gene; All |
| 42 | **End of Island** |  | 2008-01-30 → 2008-01-28 (-2d) | 25.1d → 23.25d |  |  |  |  |
| 43 | Ground plate and wiring | 2008-01-02 → 2007-12-28 (-5d) | 2008-01-14 → 2007-12-31 (-14d) |  |  | 11.29d → 18.75d |  |  |
| 44 | Build up DCS rack |  | 2008-01-03 → 2007-12-28 (-6d) | 5.32d → 3.5d |  | 18.43d → 19.75d |  | resources Ken; Gene; Pete; Craig → Ken; Pete; Craig |
| 45 | Rebuild MV rack | 2008-01-28 → 2008-01-24 (-4d) | 2008-01-30 → 2008-01-28 (-2d) |  |  |  |  |  |
| 46 | MOB | 2008-01-28 → 2008-01-24 (-4d) | 2008-01-29 → 2008-01-25 (-4d) |  |  |  |  |  |
| 47 | Deployment | 2008-01-30 → 2008-01-28 (-2d) | 2008-01-31 → 2008-01-29 (-2d) |  |  |  |  |  |

## Version 3 (saved 2007-12-26, file MARS-Dec26-2007.mpp)

Last finish stays 2008-01-29.

Changed:

| ID | Task | Start | Finish | Duration | Total float | Predecessors |
| --- | --- | --- | --- | --- | --- | --- |
| 12 | Resister Design Verification |  |  |  |  | 11 → none |
| 22 | close and fill |  |  |  | 13.12d → 1.88d | 17, 5, 21 → 17, 5, 21, 20 |
| 23 | **Closed system testing** | 2007-12-21 → 2008-01-14 (+24d) | 2008-01-10 → 2008-01-15 (+5d) | 11.5d → 1.5d | 0.5d → 0d |  |
| 24 | Operational check | 2007-12-21 → 2008-01-14 (+24d) | 2007-12-21 → 2008-01-14 (+24d) |  | 0.5d → 0d | none → 22 |
| 25 | system test | 2008-01-03 → 2008-01-14 (+11d) | 2008-01-10 → 2008-01-15 (+5d) |  | 1.75d → 0d |  |
| 26 | Build node | 2008-01-10 → 2008-01-15 (+5d) | 2008-01-14 → 2008-01-16 (+2d) | 2.5d → 1d | 1.25d → 0d |  |
| 33 | Sea water ground plates | 2008-01-14 → 2008-01-03 (-11d) | 2008-01-15 → 2008-01-10 (-5d) |  | 0.75d → 4d |  |
| 42 | **End of Island** |  |  | 23.25d → 23.5d |  |  |
| 43 | Ground plate and wiring |  | 2007-12-31 → 2007-12-28 (-3d) |  | 18.75d → 19.5d |  |
| 44 | Build up DCS rack |  |  | 3.5d → 3.17d | 19.75d → 20.33d |  |

## Version 4 (saved 2007-12-27, file MARS-Dec27-2007.mpp)

Last finish 2008-01-29 → 2008-02-20 (+22d).

Added:

| ID | Task | Duration | Start | Finish | Predecessors | Resources |
| --- | --- | --- | --- | --- | --- | --- |
| 22 | Setup | 0.5d | 2008-01-02 08:00 | 2008-01-02 12:00 |  | Gene |
| 23 | Run | 2.5d | 2008-01-02 13:00 | 2008-01-04 17:00 | 22 |  |
| 33 | Parts procurement | 1w | 2008-01-24 14:00 | 2008-01-31 14:00 | 32 |  |

Changed:

| ID | Task | Start | Finish | Duration | Total float | Predecessors | Other |
| --- | --- | --- | --- | --- | --- | --- | --- |
| 1 | **LV System Closeup** | 2007-12-21 A → 2007-12-21 08:00 A | 2008-01-08 → 2008-01-10 14:00 (+2d) | 9.62d → 11.62d | 14.88d → 29d |  |  |
| 2 | **Dry end** | 2007-12-21 → 2007-12-21 08:00 | 2007-12-27 → 2008-01-07 14:48 (+11d) | 2.02d → 8.72d | 9.47d → 16.9d |  |  |
| 3 | Install o-rings | 2007-12-21 → 2007-12-21 08:00 | 2007-12-21 → 2007-12-21 10:24 |  | 9.47d → 17.7d |  |  |
| 4 | Verify operations | 2007-12-21 → 2008-01-07 09:00 (+17d) | 2007-12-21 → 2008-01-07 09:48 (+17d) |  | 9.47d → 16.9d |  | constraint none → start no earlier than 2007-12-27 08:00; resources none → Craig; LV |
| 5 | Workmanship review | 2007-12-21 → 2008-01-07 09:48 (+17d) | 2007-12-27 → 2008-01-07 14:48 (+11d) |  | 9.47d → 16.9d |  | resources none → Craig; LV |
| 6 | **Wet end** | 2007-12-21 A → 2007-12-21 08:00 A | 2008-01-02 → 2008-01-04 14:00 (+2d) | 5.62d → 7.62d | 18.88d → 33d |  |  |
| 7 | Build up resistor bank | 2007-12-21 → 2007-12-21 08:00 | 2007-12-21 → 2007-12-21 17:00 |  |  |  |  |
| 8 | Duplicate flash disk | 2007-12-28 → 2007-12-21 13:00 (-7d) | 2007-12-28 → 2007-12-21 17:00 (-7d) |  | 20.83d → 39.62d |  |  |
| 9 | Swap in flight CPU (104) | 2007-12-21 A → 2007-12-21 08:00 A | 2007-12-21 A → 2007-12-21 12:00 A |  |  |  | constraint start no earlier than 2007-12-21 → start no earlier than 2007-12-21 08:00 |
| 10 | Install pc104 connector stops | 2007-12-21 A → 2007-12-21 08:00 A | 2007-12-21 A → 2007-12-21 12:00 A |  |  |  | constraint start no earlier than 2007-12-21 → start no earlier than 2007-12-21 08:00 |
| 11 | Install tie rods | 2007-12-21 → 2007-12-21 13:00 | 2007-12-21 → 2007-12-21 14:36 |  |  |  |  |
| 12 | Resister Design Verification | 2007-12-21 → 2007-12-27 08:00 (+6d) | 2007-12-26 → 2007-12-28 17:00 (+2d) |  | -2.5d → -4.5d |  | constraint none → start no earlier than 2007-12-27 08:00; resources Ed → Ed; LV; MV |
| 13 | Install resistor bank, route comm cables | 2007-12-27 → 2007-12-31 08:00 (+4d) | 2007-12-31 → 2008-01-03 12:00 (+3d) |  | -2.5d → -4.5d |  |  |
| 14 | Verify stability | 2007-12-31 → 2008-01-03 13:00 (+3d) | 2007-12-31 → 2008-01-03 17:00 (+3d) |  | 0.25d → 0d |  | resources Ed → Ed; LV |
| 15 | Workmanship review | 2008-01-02 → 2008-01-04 08:00 (+2d) | 2008-01-02 → 2008-01-04 12:00 (+2d) |  | 0.25d → 0d |  | resources Craig → Craig; LV |
| 16 | Verify operation | 2008-01-02 → 2008-01-04 13:00 (+2d) | 2008-01-02 → 2008-01-04 14:00 (+2d) |  | 0.25d → 0d |  |  |
| 17 | **Open System testing** | 2008-01-02 → 2008-01-04 14:00 (+2d) | 2008-01-08 → 2008-01-10 14:00 (+2d) |  | 0.25d → 0d |  |  |
| 18 | Quick and dirty dyno test | 2008-01-02 → 2008-01-04 14:00 (+2d) | 2008-01-03 → 2008-01-07 09:00 (+4d) |  | 0.25d → 0d |  |  |
| 19 | Test 2nd 10 kV PS | 2008-01-03 → 2008-01-07 09:00 (+4d) | 2008-01-03 → 2008-01-07 14:00 (+4d) |  | 0.25d → 0d |  |  |
| 20 | dry run system test | 2008-01-03 → 2008-01-07 14:00 (+4d) | 2008-01-08 → 2008-01-10 14:00 (+2d) |  | 0.25d → 0d |  |  |
| 21 | **Filter FC77** | 2007-12-21 → 2008-01-02 08:00 (+12d) | 2007-12-27 → 2008-01-04 17:00 (+8d) |  | 8.5d → 17.62d |  |  |
| 24 | close and fill | 2008-01-08 → 2008-01-10 14:00 (+2d) | 2008-01-10 → 2008-01-14 09:00 (+4d) |  | 1.88d → 14d | 17, 5, 21, 20 → 17, 5, 20, 23 |  |
| 25 | **Closed system testing** | 2008-01-14 → 2008-01-14 09:00 | 2008-01-15 → 2008-01-15 14:00 |  | 0d → 14d |  |  |
| 26 | Operational check | 2008-01-14 → 2008-01-14 09:00 | 2008-01-14 → 2008-01-14 14:00 |  | 0d → 14d |  |  |
| 27 | system test | 2008-01-14 → 2008-01-14 14:00 | 2008-01-15 → 2008-01-15 14:00 |  | 0d → 14d |  |  |
| 28 | Build node | 2008-01-15 → 2008-01-15 14:00 | 2008-01-16 → 2008-01-16 14:00 |  | 0d → 14d |  |  |
| 29 | **Build Test Tank MV Rack** | 2007-12-21 → 2007-12-21 08:00 | 2008-01-16 → 2008-02-05 14:00 (+20d) | 15.25d → 29.62d | 7d → 11d |  |  |
| 30 | **Design** | 2008-01-08 → 2008-01-10 14:00 (+2d) | 2008-01-11 → 2008-01-31 14:00 (+20d) | 2.62d → 15d | 0.25d → 0d |  |  |
| 31 | Switching/grounding circuit | 2008-01-08 → 2008-01-10 14:00 (+2d) | 2008-01-09 → 2008-01-17 14:00 (+8d) | 1d → 5d | 1.88d → 0d |  |  |
| 32 | rack wiring | 2008-01-08 → 2008-01-17 14:00 (+9d) | 2008-01-11 → 2008-01-24 14:00 (+13d) | 2d → 5d | 0.25d → 0d | none → 31 |  |
| 34 | Artificial line shelf | 2007-12-21 → 2008-01-02 08:00 (+12d) | 2007-12-26 → 2008-01-03 17:00 (+8d) |  | 22.5d → 33.62d |  | constraint none → start no earlier than 2008-01-02 08:00 |
| 35 | Build up and wire rack | 2008-01-11 → 2008-01-31 14:00 (+20d) | 2008-01-16 → 2008-02-05 14:00 (+20d) |  | 0.25d → 0d | 30 → 30, 32, 33 |  |
| 36 | Sea water ground plates | 2008-01-03 → 2008-01-03 13:00 | 2008-01-10 → 2008-01-04 12:00 (-6d) |  | 4d → 22.12d |  |  |
| 37 | **Fiber run B to D** | 2007-12-21 → 2007-12-21 08:00 | 2008-01-11 → 2008-01-07 12:00 (-4d) | 12.5d → 8.5d | 3d → 21.12d |  |  |
| 38 | Install building anchor points | 2007-12-21 → 2007-12-21 08:00 | 2007-12-21 → 2007-12-21 17:00 |  | 7d → 25.12d |  |  |
| 39 | Run cable | 2008-01-02 → 2008-01-02 13:00 | 2008-01-02 → 2008-01-03 12:00 (+1d) |  | 3d → 21.12d |  |  |
| 40 | Terminate cable | 2008-01-03 → 2008-01-03 13:00 | 2008-01-03 → 2008-01-04 12:00 (+1d) |  | 3d → 21.12d |  |  |
| 41 | Test | 2008-01-10 → 2008-01-04 13:00 (-6d) | 2008-01-11 → 2008-01-07 12:00 (-4d) |  | 3d → 21.12d |  |  |
| 42 | **Tank testing** | 2008-01-16 → 2008-02-05 14:00 (+20d) | 2008-01-24 → 2008-02-13 14:00 (+20d) |  |  |  |  |
| 43 | Build up test system | 2008-01-16 → 2008-02-05 14:00 (+20d) | 2008-01-18 → 2008-02-07 14:00 (+20d) |  |  |  |  |
| 44 | Test | 2008-01-18 → 2008-02-07 14:00 (+20d) | 2008-01-24 → 2008-02-13 14:00 (+20d) |  |  |  | resources Gene; All → Gene; All; MV; LV |
| 45 | **End of Island** | 2007-12-21 → 2007-12-27 13:48 (+6d) | 2008-01-28 → 2008-02-18 14:00 (+21d) | 23.5d → 36.02d |  |  |  |
| 46 | Ground plate and wiring | 2007-12-28 → 2008-01-03 14:36 (+6d) | 2007-12-28 → 2008-01-04 14:36 (+7d) |  | 19.5d → 30.93d |  | constraint none → start no earlier than 2007-12-27 08:00 |
| 47 | Build up DCS rack | 2007-12-21 → 2007-12-27 13:48 (+6d) | 2007-12-28 → 2008-01-03 14:36 (+6d) | 3.17d → 3.5d | 20.33d → 31.93d |  | constraint none → start no earlier than 2007-12-27 08:00 |
| 48 | Rebuild MV rack | 2008-01-24 → 2008-02-13 14:00 (+20d) | 2008-01-28 → 2008-02-18 14:00 (+21d) | 2d → 3d |  |  |  |
| 49 | MOB | 2008-01-24 → 2008-02-13 14:00 (+20d) | 2008-01-25 → 2008-02-14 14:00 (+20d) |  | 1d → 2d |  |  |
| 50 | Deployment | 2008-01-28 → 2008-02-18 14:00 (+21d) | 2008-01-29 → 2008-02-20 14:00 (+22d) | 1d → 2d |  |  |  |

## Version 5 (saved 2008-01-14, file temp.mpp)

Last finish 2008-02-20 → 2008-02-11 (-9d).

Removed: 11 Install tie rods

Changed:

| ID | Task | Start | Finish | Duration | Complete | Total float | Predecessors | Other |
| --- | --- | --- | --- | --- | --- | --- | --- | --- |
| 1 | **LV System Closeup** | 2007-12-21 08:00 A → 2007-12-21 A | 2008-01-10 14:00 → 2008-01-21 (+11d) | 11.62d → 18.5d | 8% → 7% | 29d → 15d |  |  |
| 2 | **Dry end** | 2007-12-21 08:00 → 2007-12-21 | 2008-01-07 14:48 → 2008-01-04 (-3d) | 8.72d → 7.27d |  | 16.9d → 11.23d |  |  |
| 3 | Install o-rings | 2007-12-21 08:00 → 2007-12-21 | 2007-12-21 10:24 → 2007-12-21 |  |  | 17.7d → 12.93d |  |  |
| 4 | Verify operations | 2008-01-07 09:00 → 2007-12-27 (-11d) | 2008-01-07 09:48 → 2007-12-31 (-7d) | 0.1d → 0.2d |  | 16.9d → 11.23d |  | constraint start no earlier than 2007-12-27 08:00 → start no earlier than 2007-12-27 |
| 5 | Workmanship review | 2008-01-07 09:48 → 2007-12-31 (-7d) | 2008-01-07 14:48 → 2008-01-04 (-3d) | 0.5d → 0.83d |  | 16.9d → 11.23d |  |  |
| 6 | **Wet end** | 2007-12-21 08:00 A → 2007-12-21 A | 2008-01-04 14:00 → 2008-01-10 (+6d) | 7.62d → 11.88d |  | 33d → 21.62d |  |  |
| 7 | Build up resistor bank | 2007-12-21 08:00 → 2007-12-21 | 2007-12-21 17:00 → 2007-12-21 |  |  | -1.5d → -1.62d |  |  |
| 8 | Duplicate flash disk | 2007-12-21 13:00 → 2007-12-21 | 2007-12-21 17:00 → 2007-12-21 |  |  | 39.62d → 32.5d |  |  |
| 9 | Swap in flight CPU (104) | 2007-12-21 08:00 A → 2007-12-21 A | 2007-12-21 12:00 A → 2007-12-21 A |  |  |  |  | constraint start no earlier than 2007-12-21 08:00 → start no earlier than 2007-12-21 |
| 10 | Install pc104 connector stops | 2007-12-21 08:00 A → 2007-12-21 A | 2007-12-21 12:00 A → 2007-12-21 A |  |  |  |  | constraint start no earlier than 2007-12-21 08:00 → start no earlier than 2007-12-21 |
| 11 | Resister Design Verification | 2007-12-27 08:00 → 2007-12-27 | 2007-12-28 17:00 → 2007-12-28 |  |  | -4.5d → -4.62d |  | constraint start no earlier than 2007-12-27 08:00 → start no earlier than 2007-12-27 |
| 12 | Install resistor bank, route comm cables, install tie rods | 2007-12-31 08:00 → 2008-01-07 (+7d) | 2008-01-03 12:00 → 2008-01-09 (+6d) | 2.5d → 2.62d |  | -4.5d → -8.62d | 7, 11, Install tie rods → 7, 11 | was named Install resistor bank, route comm cables; constraint none → start no earlier than 2008-01-07; resources Ken; Tom; LV → Tom; LV |
| 13 | Verify stability | 2008-01-03 13:00 → 2008-01-09 (+6d) | 2008-01-03 17:00 → 2008-01-10 (+7d) |  |  |  |  |  |
| 14 | Workmanship review | 2008-01-04 08:00 → 2008-01-10 (+6d) | 2008-01-04 12:00 → 2008-01-10 (+6d) |  |  |  |  |  |
| 15 | Verify operation | 2008-01-04 13:00 → 2008-01-10 (+6d) | 2008-01-04 14:00 → 2008-01-10 (+6d) | 0.12d → 0.25d |  |  |  | resources Ken; LV → LV |
| 16 | **Open System testing** | 2008-01-04 14:00 → 2008-01-10 (+6d) | 2008-01-10 14:00 → 2008-01-21 (+11d) | 4d → 6.62d |  |  |  |  |
| 17 | Quick and dirty dyno test | 2008-01-04 14:00 → 2008-01-10 (+6d) | 2008-01-07 09:00 → 2008-01-15 (+8d) | 0.5d → 1d |  |  |  |  |
| 18 | Test 2nd 10 kV PS | 2008-01-07 09:00 → 2008-01-16 (+9d) | 2008-01-07 14:00 → 2008-01-16 (+9d) |  |  |  |  |  |
| 19 | dry run system test | 2008-01-07 14:00 → 2008-01-16 (+9d) | 2008-01-10 14:00 → 2008-01-21 (+11d) |  |  |  |  |  |
| 20 | **Filter FC77** | 2008-01-02 08:00 → 2008-01-02 | 2008-01-04 17:00 → 2008-01-04 |  |  | 17.62d → 10.5d |  |  |
| 21 | Setup | 2008-01-02 08:00 → 2008-01-02 | 2008-01-02 12:00 → 2008-01-02 |  |  | 17.62d → 10.5d |  |  |
| 22 | Run | 2008-01-02 13:00 → 2008-01-02 | 2008-01-04 17:00 → 2008-01-04 |  |  | 17.62d → 10.5d |  |  |
| 23 | close and fill | 2008-01-10 14:00 → 2008-01-21 (+11d) | 2008-01-14 09:00 → 2008-01-22 (+8d) |  |  | 14d → 0d |  |  |
| 24 | **Closed system testing** | 2008-01-14 09:00 → 2008-01-23 (+9d) | 2008-01-15 14:00 → 2008-01-24 (+9d) |  |  | 14d → 0d |  |  |
| 25 | Operational check | 2008-01-14 09:00 → 2008-01-23 (+9d) | 2008-01-14 14:00 → 2008-01-23 (+9d) |  |  | 14d → 0d |  |  |
| 26 | system test | 2008-01-14 14:00 → 2008-01-23 (+9d) | 2008-01-15 14:00 → 2008-01-24 (+9d) |  |  | 14d → 0d |  |  |
| 27 | Build node | 2008-01-15 14:00 → 2008-01-24 (+9d) | 2008-01-16 14:00 → 2008-01-25 (+9d) |  |  | 14d → 0d |  |  |
| 28 | **Build Test Tank MV Rack** | 2007-12-21 08:00 → 2007-12-21 | 2008-02-05 14:00 → 2008-01-25 (-11d) | 29.62d → 22.5d |  | 11d → 4d |  |  |
| 29 | **Design** | 2008-01-10 14:00 → 2007-12-31 (-10d) | 2008-01-31 14:00 → 2008-01-22 (-9d) | 15d → 15.5d |  |  | 19 → none | constraint none → start no earlier than 2007-12-28 |
| 30 | Switching/grounding circuit | 2008-01-10 14:00 → 2007-12-31 (-10d) | 2008-01-17 14:00 → 2008-01-07 (-10d) |  |  |  |  |  |
| 31 | rack wiring | 2008-01-17 14:00 → 2008-01-08 (-9d) | 2008-01-24 14:00 → 2008-01-15 (-9d) |  |  |  |  |  |
| 32 | Parts procurement | 2008-01-24 14:00 → 2008-01-15 (-9d) | 2008-01-31 14:00 → 2008-01-22 (-9d) |  |  |  |  |  |
| 33 | Artificial line shelf | 2008-01-02 08:00 → 2008-01-02 | 2008-01-03 17:00 → 2008-01-03 |  |  | 33.62d → 26.5d |  | constraint start no earlier than 2008-01-02 08:00 → start no earlier than 2008-01-02 |
| 34 | Build up and wire rack | 2008-01-31 14:00 → 2008-01-22 (-9d) | 2008-02-05 14:00 → 2008-01-25 (-11d) |  |  |  |  |  |
| 35 | Sea water ground plates | 2008-01-03 13:00 → 2008-01-03 | 2008-01-04 12:00 → 2008-01-04 |  |  | 22.12d → 15d |  |  |
| 36 | **Fiber run B to D** | 2007-12-21 08:00 → 2007-12-21 | 2008-01-07 12:00 → 2008-01-07 |  |  | 21.12d → 14d |  |  |
| 37 | Install building anchor points | 2007-12-21 08:00 → 2007-12-21 | 2007-12-21 17:00 → 2007-12-21 |  |  | 25.12d → 18d |  |  |
| 38 | Run cable | 2008-01-02 13:00 → 2008-01-02 | 2008-01-03 12:00 → 2008-01-03 |  |  | 21.12d → 14d |  |  |
| 39 | Terminate cable | 2008-01-03 13:00 → 2008-01-03 | 2008-01-04 12:00 → 2008-01-04 |  |  | 21.12d → 14d |  |  |
| 40 | Test | 2008-01-04 13:00 → 2008-01-04 | 2008-01-07 12:00 → 2008-01-07 |  |  | 21.12d → 14d |  |  |
| 41 | **Tank testing** | 2008-02-05 14:00 → 2008-01-25 (-11d) | 2008-02-13 14:00 → 2008-02-04 (-9d) |  |  |  |  |  |
| 42 | Build up test system | 2008-02-05 14:00 → 2008-01-25 (-11d) | 2008-02-07 14:00 → 2008-01-29 (-9d) |  |  |  |  |  |
| 43 | Test | 2008-02-07 14:00 → 2008-01-29 (-9d) | 2008-02-13 14:00 → 2008-02-04 (-9d) |  |  |  |  |  |
| 44 | **End of Island** | 2007-12-27 13:48 → 2007-12-27 | 2008-02-18 14:00 → 2008-02-07 (-11d) | 36.02d → 29.5d |  |  |  |  |
| 45 | Ground plate and wiring | 2008-01-03 14:36 → 2008-01-02 (-1d) | 2008-01-04 14:36 → 2008-01-03 (-1d) |  |  | 30.93d → 25d |  | constraint start no earlier than 2007-12-27 08:00 → start no earlier than 2007-12-27 |
| 46 | Build up DCS rack | 2007-12-27 13:48 → 2007-12-27 | 2008-01-03 14:36 → 2008-01-02 (-1d) |  |  | 31.93d → 26d |  | constraint start no earlier than 2007-12-27 08:00 → start no earlier than 2007-12-27 |
| 47 | Rebuild MV rack | 2008-02-13 14:00 → 2008-02-04 (-9d) | 2008-02-18 14:00 → 2008-02-07 (-11d) |  |  |  |  |  |
| 48 | MOB | 2008-02-13 14:00 → 2008-02-04 (-9d) | 2008-02-14 14:00 → 2008-02-05 (-9d) |  |  |  |  |  |
| 49 | Deployment | 2008-02-18 14:00 → 2008-02-07 (-11d) | 2008-02-20 14:00 → 2008-02-11 (-9d) |  |  |  |  |  |

## Version 6 (saved 2008-01-16, file MARS-Dec28-2007.mpp)

Last finish 2008-02-11 → 2008-02-08 (-3d).

Changed:

| ID | Task | Start | Finish | Duration | Complete | Total float | Other |
| --- | --- | --- | --- | --- | --- | --- | --- |
| 1 | **LV System Closeup** |  | 2008-01-21 → 2008-01-18 (-3d) | 18.5d → 18d | 7% → 8% |  |  |
| 2 | **Dry end** |  |  | 7.27d → 7.1d |  | 11.23d → 10.9d |  |
| 4 | Verify operations | 2007-12-27 → 2008-01-03 (+7d) | 2007-12-31 → 2008-01-03 (+3d) | 0.2d → 0.1d |  | 11.23d → 10.9d |  |
| 5 | Workmanship review | 2007-12-31 → 2008-01-03 (+3d) |  | 0.83d → 0.5d |  | 11.23d → 10.9d |  |
| 6 | **Wet end** |  | 2008-01-10 → 2008-01-14 (+4d) | 11.88d → 13.12d |  | 21.62d → 19.88d |  |
| 11 | Resistor Design Verification |  |  |  |  | -4.62d → -4.5d | was named Resister Design Verification |
| 12 | Install resistor bank, route comm cables, install tie rods | 2008-01-07 → 2007-12-31 (-7d) | 2008-01-09 → 2008-01-03 (-6d) | 2.62d → 2.5d |  | -8.62d → -4.5d | constraint start no earlier than 2008-01-07 → none; resources Tom; LV → Ken; Tom; LV |
| 13 | Verify stability | 2008-01-09 → 2008-01-07 (-2d) | 2008-01-10 → 2008-01-07 (-3d) |  |  | 0d → 3.5d |  |
| 14 | Workmanship review | 2008-01-10 → 2008-01-08 (-2d) | 2008-01-10 → 2008-01-08 (-2d) |  |  | 0d → 3.5d |  |
| 15 | Verify operation | 2008-01-10 → 2008-01-08 (-2d) | 2008-01-10 → 2008-01-14 (+4d) |  |  |  | resources LV → Ken; LV |
| 16 | **Open System testing** | 2008-01-10 → 2008-01-15 (+5d) | 2008-01-21 → 2008-01-18 (-3d) | 6.62d → 4d |  |  |  |
| 17 | Quick and dirty dyno test | 2008-01-10 → 2008-01-15 (+5d) |  | 1d → 0.5d |  |  |  |
| 18 | Test 2nd 10 kV PS | 2008-01-16 → 2008-01-15 (-1d) | 2008-01-16 → 2008-01-15 (-1d) |  |  |  |  |
| 19 | dry run system test |  | 2008-01-21 → 2008-01-18 (-3d) |  |  |  |  |
| 24 | **Closed system testing** | 2008-01-23 → 2008-01-22 (-1d) | 2008-01-24 → 2008-01-23 (-1d) |  |  |  |  |
| 25 | Operational check | 2008-01-23 → 2008-01-22 (-1d) | 2008-01-23 → 2008-01-22 (-1d) |  |  |  |  |
| 26 | system test |  | 2008-01-24 → 2008-01-23 (-1d) |  |  |  |  |
| 27 | Build node |  | 2008-01-25 → 2008-01-24 (-1d) |  |  |  |  |
| 28 | **Build Test Tank MV Rack** |  | 2008-01-25 → 2008-01-24 (-1d) | 22.5d → 22d |  |  |  |
| 29 | **Design** |  | 2008-01-22 → 2008-01-21 (-1d) | 15.5d → 15d |  |  |  |
| 31 | rack wiring |  | 2008-01-15 → 2008-01-14 (-1d) |  |  |  |  |
| 32 | Parts procurement |  | 2008-01-22 → 2008-01-21 (-1d) |  |  |  |  |
| 34 | Build up and wire rack |  | 2008-01-25 → 2008-01-24 (-1d) |  |  |  |  |
| 41 | **Tank testing** |  | 2008-02-04 → 2008-02-01 (-3d) |  |  |  |  |
| 42 | Build up test system |  | 2008-01-29 → 2008-01-28 (-1d) |  |  |  |  |
| 43 | Test |  | 2008-02-04 → 2008-02-01 (-3d) |  |  |  |  |
| 44 | **End of Island** |  | 2008-02-07 → 2008-02-06 (-1d) | 29.5d → 28.4d |  |  |  |
| 45 | Ground plate and wiring | 2008-01-02 → 2008-01-03 (+1d) | 2008-01-03 → 2008-01-04 (+1d) |  |  | 25d → 23.3d |  |
| 46 | Build up DCS rack |  | 2008-01-02 → 2008-01-03 (+1d) |  |  | 26d → 24.3d |  |
| 47 | Rebuild MV rack |  | 2008-02-07 → 2008-02-06 (-1d) |  |  |  |  |
| 48 | MOB |  | 2008-02-05 → 2008-02-04 (-1d) |  |  |  |  |
| 49 | Deployment |  | 2008-02-11 → 2008-02-08 (-3d) |  |  |  |  |

## Version 7 (saved 2008-01-16, file MARS-Jan16-2008.mpp)

Last finish 2008-02-08 → 2008-02-20 (+12d). Complete tasks 2 → 8.

Added:

| ID | Task | Duration | Start | Finish | Predecessors | Constraint | Resources |
| --- | --- | --- | --- | --- | --- | --- | --- |
| 30 | Design | 5d | 2008-01-11 | 2008-01-17 |  | start no earlier than 2008-01-11 | Ed |
| 32 | Build box and wire | 3d | 2008-01-29 | 2008-01-31 | 31 |  | Ed; Tom |
| 47 | rack wiring design | 5d | 2008-01-22 | 2008-01-28 |  | start no earlier than 2008-01-16 | Ed |

Removed: 29 Design; 31 rack wiring

Changed:

| ID | Task | Start | Finish | Duration | Complete | Total float | Predecessors | Other |
| --- | --- | --- | --- | --- | --- | --- | --- | --- |
| 1 | **LV System Closeup** |  | 2008-01-18 → 2008-01-24 (+6d) | 18d → 21d | 8% → 39% | 15d → 19d |  |  |
| 2 | **Dry end** |  |  | 7.1d → 7.43d |  | 10.9d → 17.57d |  |  |
| 4 | Verify operations | 2008-01-03 → 2007-12-27 (-7d) | 2008-01-03 → 2007-12-31 (-3d) | 0.1d → 0.2d |  | 10.9d → 17.9d |  |  |
| 5 | Workmanship review |  |  | 0.5d → 0.67d |  | 10.9d → 17.57d |  |  |
| 6 | **Wet end** |  |  | 13.12d → 13.06d | 12% → 65% | 19.88d → 26.94d |  |  |
| 7 | Build up resistor bank | 2007-12-21 → 2008-01-03 (+13d) | 2007-12-21 → 2008-01-04 (+14d) |  |  | -1.5d → 32.5d |  |  |
| 11 | Resistor Design Verification | 2007-12-27 A | 2007-12-28 A |  | 0% → 100% | -4.5d → none |  |  |
| 12 | Install resistor bank, route comm cables, install tie rods | 2007-12-31 A | 2008-01-03 A | 2.5d → 2.6d | 0% → 100% | -4.5d → none |  |  |
| 13 | Verify stability | 2008-01-07 → 2008-01-03 (-4d) | 2008-01-07 → 2008-01-04 (-3d) |  |  | 3.5d → 9d |  |  |
| 14 | Workmanship review | 2008-01-08 → 2008-01-04 (-4d) | 2008-01-08 → 2008-01-04 (-4d) | 0.5d → 0.83d |  | 3.5d → 9d |  |  |
| 15 | Verify operation | 2008-01-08 → 2008-01-04 (-4d) |  | 0.25d → 0.18d |  | 0d → 4d |  |  |
| 16 | **Open System testing** | 2008-01-15 → 2008-01-14 (-1d) | 2008-01-18 → 2008-01-24 (+6d) | 4d → 7.94d |  | 0d → 4d |  |  |
| 17 | Quick and dirty dyno test | 2008-01-15 → 2008-01-14 (-1d) | 2008-01-15 → 2008-01-18 (+3d) | 0.5d → 1d |  | 0d → 4d |  |  |
| 18 | Test 2nd 10 kV PS | 2008-01-15 → 2008-01-18 (+3d) | 2008-01-15 → 2008-01-18 (+3d) |  |  | 0d → 4d |  |  |
| 19 | dry run system test | 2008-01-16 → 2008-01-22 (+6d) | 2008-01-18 → 2008-01-24 (+6d) |  |  | 0d → 4d |  |  |
| 20 | **Filter FC77** | 2008-01-02 → 2007-12-21 (-12d) | 2008-01-04 → 2007-12-27 (-8d) |  |  | 10d → 22d |  |  |
| 21 | Setup | 2008-01-02 → 2007-12-21 (-12d) | 2008-01-02 → 2007-12-21 (-12d) |  |  | 10d → 22d |  |  |
| 22 | Run | 2008-01-02 → 2007-12-21 (-12d) | 2008-01-04 → 2007-12-27 (-8d) |  |  | 10d → 22d |  |  |
| 23 | close and fill | 2008-01-21 → 2008-01-25 (+4d) | 2008-01-22 → 2008-01-28 (+6d) |  |  | 0d → 4d |  |  |
| 24 | **Closed system testing** | 2008-01-22 → 2008-01-28 (+6d) | 2008-01-23 → 2008-01-29 (+6d) |  |  | 0d → 4d |  |  |
| 25 | Operational check | 2008-01-22 → 2008-01-28 (+6d) | 2008-01-22 → 2008-01-28 (+6d) |  |  | 0d → 4d |  |  |
| 26 | system test | 2008-01-23 → 2008-01-29 (+6d) | 2008-01-23 → 2008-01-29 (+6d) |  |  | 0d → 4d |  |  |
| 27 | Build node | 2008-01-24 → 2008-01-30 (+6d) | 2008-01-24 → 2008-01-30 (+6d) |  |  | 0d → 4d |  |  |
| 28 | **Build Test Tank MV Rack** | 2007-12-21 A | 2008-01-24 → 2008-02-05 (+12d) | 22d → 29d | 0% → 17% | 4d → 0d |  |  |
| 29 | **Switching/grounding circuit** | 2007-12-31 → 2008-01-11 (+11d) | 2008-01-07 → 2008-01-31 (+24d) | 5d → 14d |  |  |  | resources Ed → none |
| 31 | Parts procurement | 2008-01-15 → 2008-01-18 (+3d) | 2008-01-21 → 2008-01-28 (+7d) | 1w → 6d |  |  | rack wiring → 30 |  |
| 33 | Artificial line shelf | 2008-01-02 → 2008-01-18 (+16d) | 2008-01-03 → 2008-01-22 (+19d) |  |  | 26d → 7d |  | constraint start no earlier than 2008-01-02 → finish no earlier than 2008-01-22 |
| 34 | Build up and wire rack | 2008-01-22 → 2008-02-01 (+10d) | 2008-01-24 → 2008-02-05 (+12d) |  |  |  | Design, rack wiring, 31 → 33, 29, 47 |  |
| 35 | Sea water ground plates | 2008-01-03 → 2007-12-21 (-13d) | 2008-01-04 → 2008-01-02 (-2d) |  |  | 14.5d → 23.5d |  |  |
| 36 | **Fiber run B to D** | 2007-12-21 A | 2008-01-07 A |  | 0% → 100% | 13.5d → none |  |  |
| 37 | Install building anchor points | 2007-12-21 A | 2007-12-21 A |  | 0% → 100% | 18d → none |  |  |
| 38 | Run cable | 2008-01-02 A | 2008-01-03 A |  | 0% → 100% | 13.5d → none |  |  |
| 39 | Terminate cable | 2008-01-03 A | 2008-01-04 A |  | 0% → 100% | 13.5d → none |  |  |
| 40 | Test | 2008-01-04 A | 2008-01-07 A |  | 0% → 100% | 13.5d → none |  |  |
| 41 | **Tank testing** | 2008-01-25 → 2008-02-06 (+12d) | 2008-02-01 → 2008-02-13 (+12d) |  |  |  |  |  |
| 42 | MOB in test tank area | 2008-01-25 → 2008-02-06 (+12d) | 2008-01-28 → 2008-02-07 (+10d) |  |  |  |  | was named Build up test system |
| 43 | Test | 2008-01-29 → 2008-02-08 (+10d) | 2008-02-01 → 2008-02-13 (+12d) |  |  |  |  |  |
| 44 | **End of Island** |  | 2008-02-06 → 2008-02-18 (+12d) | 28.4d → 36d |  |  |  |  |
| 45 | Ground plate and wiring | 2008-01-03 → 2008-01-16 (+13d) | 2008-01-04 → 2008-01-16 (+12d) |  |  | 23.3d → 22d |  | constraint start no earlier than 2007-12-27 → start no earlier than 2008-01-16 |
| 46 | Build up DCS rack |  | 2008-01-03 → 2008-01-02 (-1d) | 3.5d → 3.75d |  | 24.3d → 32.25d |  |  |
| 48 | Rebuild MV rack | 2008-02-04 → 2008-02-14 (+10d) | 2008-02-06 → 2008-02-18 (+12d) |  |  |  | 41 → 41, 47 |  |
| 49 | MOB | 2008-02-04 → 2008-02-14 (+10d) | 2008-02-04 → 2008-02-14 (+10d) |  |  |  |  |  |
| 50 | Deployment | 2008-02-07 → 2008-02-19 (+12d) | 2008-02-08 → 2008-02-20 (+12d) |  |  |  |  |  |
